# Maison Guillet

Schedule from GanttProject, 2010-09-06 to 2011-05-26, baseline: Gantt initial.

## Calendars

- Project calendar: Mon-Fri working; Sat-Sun off. Exceptions (off unless hours are given): 2010-11-11, 2010-12-25, 2011-01-01, 2011-05-01, 2011-05-08.

## Schedule

| ID | Task | Duration | Start | Finish | Complete | Baseline start | Baseline finish | Baseline duration | Baseline 1 start | Baseline 1 finish |
| --- | --- | --- | --- | --- | --- | --- | --- | --- | --- | --- |
| 1 | Terrassement | 2d | 2010-09-06 | 2010-09-07 | 100% | 2010-09-07 | 2010-09-07 | 1d | 2010-09-06 | 2010-09-07 |
| 2 | Fondations | 1d | 2010-09-08 | 2010-09-08 | 100% | 2010-09-13 | 2010-09-16 | 4d | 2010-09-08 | 2010-09-08 |
| 3 | Séchage fondations | 10d | 2010-09-09 | 2010-09-22 | 100% | 2010-09-17 | 2010-09-30 | 10d | 2010-09-09 | 2010-09-22 |
| 4 | Dalle béton | 6d | 2010-10-11 | 2010-10-18 | 100% | 2010-10-01 | 2010-10-08 | 6d | 2010-10-11 | 2010-10-18 |
| 5 | Séchage dalle | 14d | 2010-10-19 | 2010-11-05 | 100% | 2010-10-11 | 2010-10-29 | 15d | 2010-10-19 | 2010-11-05 |
| 6 | Taille MOB | 10d | 2010-11-08 | 2010-11-22 | 100% | 2010-11-01 | 2010-11-15 | 10d | 2010-11-08 | 2010-11-22 |
| 7 | Congés | 6d | 2010-12-24 | 2010-12-31 | 100% | 2010-12-24 | 2010-12-31 | 6d | 2010-12-24 | 2010-12-31 |
| 8 | Pose MOB | 10d | 2011-01-04 | 2011-01-17 | 100% | 2010-11-29 | 2010-12-10 | 10d | 2010-11-29 | 2010-12-10 |
| 9 | Charpente | 10d | 2011-01-17 | 2011-01-28 | 100% | 2010-12-13 | 2010-12-23 | 9d | 2010-12-13 | 2010-12-23 |
| 10 | Garage maçonné | 15d | 2011-01-17 | 2011-02-04 | 100% |  |  |  |  |  |
| 11 | Couverture | 10d | 2011-01-31 | 2011-02-11 | 100% | 2011-01-03 | 2011-01-14 | 10d | 2011-01-03 | 2011-01-14 |
| 12 | Menuiseries | 3d | 2011-03-07 | 2011-03-09 | 100% | 2011-01-17 | 2011-01-19 | 3d | 2011-01-17 | 2011-01-19 |
| 13 | Réunion chantier hors eau hors air | 1d | 2011-03-14 | 2011-03-14 | 100% | 2011-01-20 | 2011-01-20 | 1d | 2011-01-20 | 2011-01-20 |
| 14 | Isolation | 7d | 2011-03-14 | 2011-03-22 | 72% | 2011-01-21 | 2011-02-10 | 15d | 2011-01-21 | 2011-02-10 |
| 15 | Installation BSO | 2d | 2011-03-28 | 2011-03-29 |  |  |  |  |  |  |
| 16 | Elec. 1ère | 9d | 2011-03-21 | 2011-03-31 |  | 2011-02-14 | 2011-02-18 | 5d | 2011-02-14 | 2011-02-18 |
| 17 | Plomberie 1ère | 9d | 2011-03-21 | 2011-03-31 |  | 2011-02-21 | 2011-02-25 | 5d | 2011-02-21 | 2011-02-25 |
| 18 | Blower door test | 1d | 2011-04-01 | 2011-04-01 |  | 2011-02-28 | 2011-02-28 | 1d | 2011-02-28 | 2011-02-28 |
| 19 | Bardage | 15d | 2011-04-04 | 2011-04-22 |  | 2011-03-01 | 2011-03-18 | 14d | 2011-03-01 | 2011-03-18 |
| 20 | Placo | 15d | 2011-04-04 | 2011-04-22 |  | 2011-03-01 | 2011-03-21 | 15d | 2011-03-01 | 2011-03-21 |
| 21 | Isolation plancher | 2d | 2011-04-25 | 2011-04-26 |  | 2011-03-22 | 2011-03-23 | 2d | 2011-03-22 | 2011-03-23 |
| 22 | Chape | 3d | 2011-04-27 | 2011-04-29 |  | 2011-03-24 | 2011-03-28 | 3d | 2011-03-24 | 2011-03-28 |
| 23 | Terrassement finitions | 2d | 2011-05-02 | 2011-05-03 |  |  |  |  |  |  |
| 24 | Carrelage | 7d | 2011-05-02 | 2011-05-10 |  | 2011-03-29 | 2011-04-18 | 15d | 2011-03-29 | 2011-04-18 |
| 25 | Plomberie finition | 6d | 2011-05-11 | 2011-05-18 |  | 2011-04-19 | 2011-04-25 | 5d | 2011-04-19 | 2011-04-25 |
| 26 | Elec. finition | 6d | 2011-05-11 | 2011-05-18 |  | 2011-04-26 | 2011-05-02 | 5d | 2011-04-26 | 2011-05-02 |
| 27 | Escalier | 1d | 2011-05-19 | 2011-05-19 |  | 2011-05-03 | 2011-05-03 | 1d | 2011-05-03 | 2011-05-03 |
| 28 | Finitions | 4d | 2011-05-20 | 2011-05-25 |  | 2011-05-04 | 2011-05-17 | 10d | 2011-05-04 | 2011-05-17 |
| 29 | Réception | 1d | 2011-05-26 | 2011-05-26 |  | 2011-05-18 | 2011-05-18 | 1d | 2011-05-18 | 2011-05-18 |
